# Juniper Nursing Home - modified for Logic Reader

Schedule from Primavera P6, 2025-02-26 to 2033-02-04, data date 2025-02-26.

## Calendars

- Trades - 5 Day Workweek: Mon-Fri 08:00-12:00, 13:00-17:00; Sat-Sun off.

## Schedule

| ID | WBS | Activity | Type | Duration | Start | Finish | Predecessors | Total float | Free float | Key Milestones | Department | Responsibility | Phase |
| --- | --- | --- | --- | --- | --- | --- | --- | --- | --- | --- | --- | --- | --- |
| 101010 |  | Building Pad Delivered by Owner | milestone | 0d | 2025-02-26 | 2025-02-26 |  | 0d |  | Key MS | CON | NOLAN | FOUND |
| 101060 |  | Curbing | milestone | 0d | 2025-02-26 | 2025-02-26 | 101010 | 0d |  | Key MS | ENG | FOLEY | DESGN |
| 102300 |  | Substantial Completion - All TCO | milestone | 0d | 2033-02-04 | 2033-02-04 | 102310, 101520, 101160, 101100, 102260, 101230, 102060, 102290, 101040 FF, 101050 FF, 101530 FF | 0d |  | Key MS | CON | MILLS | FINSH |
|  | 1 | **Building 1** |  |  | 2025-06-24 | 2032-10-19 |  |  |  |  |  |  |  |
| 102310 |  | Complete Building 1 | milestone | 0d | 2032-10-19 | 2032-10-19 | 101550, 101890, 102240, 101590, 101690, 102130 FF, 102230, 102120, 101750, 102150, 101480, 101620, 102170, 102270, 101850, 101680, 102020, 101810, 101970, 102140 | 78.7d |  | Key MS | CON | MILLS | FINSH |
|  | 1 | **Structure** |  |  | 2025-06-24 | 2026-04-14 |  |  |  |  |  |  |  |
| 101070 |  | Building Pad Including UG Utils |  | 48.12d | 2025-06-24 | 2025-08-29 | 101060, 101090 | 0d |  |  | CON | NOLAN | FOUND |
| 101110 |  | First Floor Masonry Structure |  | 12d | 2025-08-29 | 2025-09-16 | 101070 | 78.7d | 0d |  | CON | FOLEY | FOUND |
| 101130 |  | Second Floor Slab & Collar Beam |  | 24d | 2025-09-16 | 2025-10-20 | 101110 | 78.7d | 0d |  | CON | NOLAN | FOUND |
| 101150 |  | Second Floor Masonry Structure |  | 12d | 2025-10-20 | 2025-11-05 | 101130 | 78.7d | 0d |  | ENG | FOLEY | FOUND |
| 101170 |  | Third Floor Slab & Collar Beam |  | 24.12d | 2025-11-05 | 2025-12-09 | 101150 | 78.7d | 0d |  | ENG | FOLEY | FOUND |
| 101200 |  | Third Floor Masonry Structure |  | 12.12d | 2025-12-09 | 2025-12-25 | 101170 | 78.7d | 0d |  | ENG | FOLEY | FOUND |
| 101210 |  | Fourth Floor Slab & Collar Beam |  | 24.12d | 2025-12-25 | 2026-01-28 | 101200 | 78.7d | 0d |  | ENG | FOLEY | FOUND |
| 101260 |  | Fourth Floor Masonry Structure |  | 12.12d | 2026-01-28 | 2026-02-13 | 101210 | 78.7d | 0d |  | CON | FOLEY | FOUND |
| 101270 |  | Roof Slab |  | 24.12d | 2026-02-13 | 2026-03-19 | 101260 | 78.7d | 0d |  | CON | FOLEY | FOUND |
| 101300 |  | Stair and Elevator Masonry Structure |  | 4.92d | 2026-03-20 | 2026-03-26 | 101270 | 78.7d | 0d |  | CON | EVANS | FOUND |
| 101310 |  | Roof Slab/Collar Beam |  | 12.12d | 2026-03-26 | 2026-04-14 | 101300 | 78.7d | 0d |  | CON | EVANS | FOUND |
|  | 2 | **Roof** |  |  | 2026-04-14 | 2026-07-20 |  |  |  |  |  |  |  |
| 101340 |  | Place Roof Trusses and Sheathing |  | 24.12d | 2026-04-14 | 2026-05-18 | 101310 | 78.7d | 0d |  | CON | EVANS | STRUC |
| 101350 |  | Place Mechanical Equipment Supports |  | 24.12d | 2026-04-14 | 2026-05-18 | 101310 | 90.7d | 0d |  | CON | EVANS | STRUC |
| 101460 |  | Built-Up Asphalt Roofing |  | 33.73d | 2026-05-18 | 2026-07-02 | 101350 | 90.7d | 12d |  | ENG | EVANS | STRUC |
| 101470 |  | Felt and Tile Roofing |  | 45.73d | 2026-05-18 | 2026-07-20 | 101340 | 78.7d | 0d |  | CON | EVANS | STRUC |
| 101680 |  | Roof Complete | milestone | 0d | 2026-07-20 | 2026-07-20 | 101460, 101010, 101470 | 804d | 196.93d | Key MS | CON | EVANS | STRUC |
|  | 3 | **Envelope** |  |  | 2026-04-14 | 2027-02-01 |  |  |  |  |  |  |  |
| 101320 |  | Mobilize Scaffolding |  | 12.12d | 2026-04-14 | 2026-04-30 | 101310 | 1151.62d | 7.2d |  | CON | EVANS | CLOSE |
| 101360 |  | Install Exterior Windows and Sliding Glass Doors Floor 1 |  | 19.32d | 2026-04-14 | 2026-05-11 | 101310 | 1113.22d | 0d |  | CON | EVANS | CLOSE |
| 101400 |  | Install Exterior Windows and Sliding Glass Doors Floor 2 |  | 19.32d | 2026-05-11 | 2026-06-05 | 101360 | 1113.22d | 0d |  | ENG | EVANS | CLOSE |
| 101420 |  | Install Backing & Cauld Windows Floor1 |  | 9.72d | 2026-05-11 | 2026-05-25 | 101360, 101320 | 1144.42d | 9.6d |  | CON | EVANS | CLOSE |
| 101430 |  | Install Exterior Windows and Sliding Glass Doors Floor 3 |  | 16.93d | 2026-06-05 | 2026-06-30 | 101400 | 1113.22d | 0d |  | ENG | EVANS | CLOSE |
| 101440 |  | Install Backing & Cauld Windows Floor 2 |  | 9.72d | 2026-06-05 | 2026-06-19 | 101400, 101420 | 1134.83d | 7.2d |  | CON | EVANS | CLOSE |
| 101450 |  | Install Exterior Windows and Sliding Glass Doors Floor 4 |  | 21.73d | 2026-06-30 | 2026-07-30 | 101430 | 1113.22d | 0d |  | ENG | EVANS | CLOSE |
| 101490 |  | Install Backing & Cauld Windows Floor 3 |  | 7.33d | 2026-06-30 | 2026-07-09 | 101430, 101440 | 1127.62d | 14.4d |  | CON | EVANS | CLOSE |
| 101570 |  | Install Backing & Cauld Windows Floor 4 |  | 9.6d | 2026-07-30 | 2026-08-12 | 101450, 101490 | 1113.22d | 0d |  | CON | EVANS | CLOSE |
| 101500 |  | Stucco Bands |  | 9.6d | 2026-08-12 | 2026-08-26 | 101570, 101440 | 1113.22d | 0d |  | ENG | EVANS | CLOSE |
| 101580 |  | Stucco Grey |  | 19.2d | 2026-08-26 | 2026-09-22 | 101500 | 1113.22d | 0d |  | CON | EVANS | CLOSE |
| 101610 |  | Stucco Finish Coat |  | 24d | 2026-09-22 | 2026-10-26 | 101580 | 1113.22d | 0d |  | CON | EVANS | CLOSE |
| 101740 |  | Caulk |  | 9.6d | 2026-10-26 | 2026-11-09 | 101610 | 1113.22d | 0d |  | CON | HARIS | CLOSE |
| 101800 |  | Stucco Band Trim |  | 12d | 2026-11-09 | 2026-11-25 | 101740 | 1113.22d | 0d |  | CON | HARIS | CLOSE |
| 101880 |  | Paint Exterior |  | 12d | 2026-11-25 | 2026-12-11 | 101800 | 1113.22d | 0d |  | CON | HARIS | CLOSE |
| 101890 |  | Install Railings |  | 36d | 2026-12-11 | 2027-02-01 | 101880 | 1209.47d | 0d |  | CON | MILLS | CLOSE |
| 101990 |  | Demobilize Scaffolding |  | 12.12d | 2026-12-11 | 2026-12-29 | 101880 | 1113.22d | 0d |  | CON | HARIS | CLOSE |
| 102020 |  | Shell Complete | milestone | 0d | 2027-02-01 | 2027-02-01 | 101990, 101890 | 1209.47d | 14.4d | Key MS | CON | MILLS | CLOSE |

| ID | WBS | Activity | Type | Duration | Start | Finish | Predecessors | Total float | Free float | Department | Responsibility | Phase | Key Milestones |
| --- | --- | --- | --- | --- | --- | --- | --- | --- | --- | --- | --- | --- | --- |
|  | 4 | **Interior Finishes** |  |  | 2026-07-20 | 2032-10-19 |  |  |  |  |  |  |  |
| 101480 |  | Unit Finishes Building North - Floor 1 |  | 196.93d | 2026-07-20 | 2027-04-21 | 101470, 101460 | 78.7d | 0d | ENG | EVANS | FINSH |  |
| 101550 |  | Unit Finishes Building South - Floor 1 |  | 199.32d | 2027-04-21 | 2028-01-26 | 101480 | 78.7d | 0d | CON | EVANS | FINSH |  |
| 101720 |  | Building 2 Elevators Complete |  | 69.6d | 2027-04-21 | 2027-07-28 | 101680, 101390, 101480 | 607.08d | 528.38d | CON | HARIS | FINSH |  |
| 101590 |  | Unit Finishes Building North - Floor 2 |  | 199.32d | 2028-01-26 | 2028-10-31 | 101550 | 78.7d | 0d | CON | EVANS | FINSH |  |
| 102120 |  | Tenant Finishes for Clubhouse Areas |  | 127.33d | 2028-01-26 | 2028-07-21 | 101550 | 1151.88d | 1073.17d | CON | MILLS | FINSH |  |
| 101620 |  | Unit Finishes Building South - Floor 2 |  | 199.32d | 2028-10-31 | 2029-08-06 | 101590 | 78.7d | 0d | CON | EVANS | FINSH |  |
| 101690 |  | Unit Finishes Building North - Floor 3 |  | 199.32d | 2029-08-06 | 2030-05-13 | 101720, 101620 | 78.7d | 0d | CON | EVANS | FINSH |  |
| 101750 |  | Unit Finishes Building South - Floor 3 |  | 199.32d | 2030-05-13 | 2031-02-14 | 101690 | 78.7d | 0d | CON | HARIS | FINSH |  |
| 101810 |  | Unit Finishes Building North - Floor 4 |  | 201.6d | 2031-02-14 | 2031-11-25 | 101750 | 78.7d | 0d | CON | HARIS | FINSH |  |
| 101850 |  | Unit Finishes Building South - Floor 4 |  | 201.6d | 2031-11-25 | 2032-09-01 | 101810 | 78.7d | 0d | CON | HARIS | FINSH |  |
| 102240 |  | Final Inspections and Punchlist |  | 33.6d | 2032-09-01 | 2032-10-19 | 101620, 101550, 101810, 101590, 101690, 101480, 101750, 101850, 102120 | 78.7d | 0d | CON | MILLS | FINSH |  |
|  | 5 | **Pool & Courtyard** |  |  | 2026-12-29 | 2027-09-23 |  |  |  |  |  |  |  |
| 101970 |  | Pool & Deck |  | 141.72d | 2026-12-29 | 2027-07-15 | 101990, 101470 | 1113.22d | 0d | CON | HARIS | FINSH |  |
| 102150 |  | Pergola and Amenities |  | 50.52d | 2027-07-15 | 2027-09-23 | 101970 | 1113.22d | 0d | ENG | MILLS | FINSH |  |
|  | 2 | **Building 2** |  |  | 2025-08-29 | 2033-02-04 |  |  |  |  |  |  |  |
| 102290 |  | Complete Building 2 | milestone | 0d | 2033-02-04 | 2033-02-04 | 102050, 102090, 102280, 102000, 102220, 102030, 101960, 101920, 102080, 102210 | 0d |  | CON | MILLS | DESGN | Key MS |
|  | 1 | **Structure** |  |  | 2025-08-29 | 2026-07-02 |  |  |  |  |  |  |  |
| 101120 |  | Building Slab Incl. UG Utils |  | 48d | 2025-08-29 | 2025-11-05 | 101060, 101070 | 0d |  | CON | FOLEY | FOUND |  |
| 101180 |  | First Floor Masonry Structure |  | 12d | 2025-11-05 | 2025-11-21 | 101120 | 0d |  | ENG | FOLEY | FOUND |  |
| 101190 |  | Second Floor Slab & Collar Beam |  | 24.12d | 2025-11-21 | 2025-12-25 | 101180 | 0d |  | ENG | NOLAN | FOUND |  |
| 101220 |  | Second Floor Masonry Structure |  | 12.12d | 2025-12-25 | 2026-01-12 | 101190 | 0d |  | ENG | NOLAN | FOUND |  |
| 101250 |  | Third Floor Slab & Collar Beam |  | 24.12d | 2026-01-12 | 2026-02-13 | 101220 | 0d |  | ENG | NOLAN | FOUND |  |
| 101280 |  | Third Floor Masonry Structure |  | 12.12d | 2026-02-13 | 2026-03-03 | 101250 | 0d |  | CON | FOLEY | FOUND |  |
| 101290 |  | Fourth Floor Slab & Collar Beam |  | 24.12d | 2026-03-03 | 2026-04-06 | 101280 | 0d |  | CON | FOLEY | FOUND |  |
| 101330 |  | Fourth Floor Masonry Structure |  | 12.12d | 2026-04-07 | 2026-04-23 | 101290 | 0d |  | CON | EVANS | FOUND |  |
| 101410 |  | Roof Slab |  | 21.73d | 2026-04-23 | 2026-05-22 | 101330 | 0d |  | ENG | EVANS | FOUND |  |
| 101540 |  | Stair and Elevator Masonry Structure |  | 4.92d | 2026-05-22 | 2026-05-29 | 101410 | 0d |  | CON | EVANS | FOUND |  |
| 101560 |  | Roof Slab/Collar Beam |  | 24.12d | 2026-05-29 | 2026-07-02 | 101540 | 0d |  | CON | EVANS | FOUND |  |

Notes:
- 101590: Steps: Install Plumbing Risers; Sprinkler Rough In; Layout and Top Rack; Electrical Rough In; Interior Rough and Finishes; HVAC Duct Rough In; HVAC Rough Inspection; Frame Walls & Soffits & Prehang; Install Plumbing In Walls; Electrical Wiring; Plumbing Rough Inspection; Electrical Rough Inspection; Framing Inspection; Install Insulation & Drywall One Side; Install Drywall 2nd Side; Finish Drywall (Bead, Tape, Knockdown Texture); Cut Plugs & Switches; Install Interior Door Frames; Interior Trim & Millwork; Paint; Install Cabinet Carcasss; Tile Kitchen, Foyer & Baths; Install Kit Plumbing Fixtures; Install Bath Mirrors & Enclosures; Install Bath Harware & Accessories; Finish Kitchen & Bath Plumbing; Paint 2nd Coat; Finish Plumbing Inspection; Install HVAC Unit & Startup; Carpet Units; Install Interior Doors; Install Security Finishes; Touch Up Drywall; Install Appliances; Touch Up Paint; Punchlist

| ID | WBS | Activity | Type | Duration | Start | Finish | Predecessors | Total float | Free float | Department | Responsibility | Phase | Key Milestones |
| --- | --- | --- | --- | --- | --- | --- | --- | --- | --- | --- | --- | --- | --- |
|  | 2 | **Roof** |  |  | 2026-07-02 | 2026-10-08 |  |  |  |  |  |  |  |
| 101630 |  | Place Roof Trusses and Sheathing |  | 24.12d | 2026-07-02 | 2026-08-06 | 101560 | 0d |  | CON | EVANS | ROUGH |  |
| 101640 |  | Place Mechanical Equipment Supports |  | 24.12d | 2026-07-02 | 2026-08-06 | 101560 | 12d | 0d | CON | EVANS | ROUGH |  |
| 101760 |  | Built-Up Asphalt Roofing |  | 33.73d | 2026-08-06 | 2026-09-22 | 101640 | 12d |  | CON | HARIS | ROUGH |  |
| 101770 |  | Felt and Tile Roofing |  | 45.73d | 2026-08-06 | 2026-10-08 | 101630 | 0d |  | CON | HARIS | ROUGH |  |
| 101910 |  | Roof Complete | milestone | 0d | 2026-10-08 | 2026-10-08 | 101760, 101120 FF, 101770 | 727.2d | 0d | CON | HARIS | ROUGH | Key MS |
|  | 3 | **Envelope** |  |  | 2026-07-02 | 2027-08-04 |  |  |  |  |  |  |  |
| 101650 |  | Install Exterior Windows and Sliding Glass Doors Floor 1 |  | 24.12d | 2026-07-02 | 2026-08-06 | 101560 | 1357.78d | 0d | CON | EVANS | CLOSE |  |
| 101660 |  | Mobilize Scaffolding |  | 12.12d | 2026-07-02 | 2026-07-21 | 101560 | 1403.38d | 12d | CON | MILLS | CLOSE |  |
| 101700 |  | Install Exterior Windows and Sliding Glass Doors Floor 2 |  | 21.73d | 2026-08-06 | 2026-09-04 | 101650 | 1357.78d | 0d | CON | EVANS | CLOSE |  |
| 101730 |  | Install Backing & Cauld Windows Floor1 |  | 12.12d | 2026-08-06 | 2026-08-24 | 101650, 101660 | 1391.38d | 9.6d | CON | MILLS | CLOSE |  |
| 101780 |  | Install Exterior Windows and Sliding Glass Doors Floor 3 |  | 21.6d | 2026-09-04 | 2026-10-06 | 101700 | 1357.78d | 0d | CON | HARIS | CLOSE |  |
| 101790 |  | Install Backing & Cauld Windows Floor 2 |  | 9.6d | 2026-09-04 | 2026-09-18 | 101730, 101700 | 1381.78d | 12d | CON | HARIS | CLOSE |  |
| 101820 |  | Install Exterior Windows and Sliding Glass Doors Floor 4 |  | 24d | 2026-10-06 | 2026-11-09 | 101780 | 1357.78d | 0d | CON | HARIS | CLOSE |  |
| 101830 |  | Install Backing & Cauld Windows Floor 3 |  | 12d | 2026-10-06 | 2026-10-22 | 101780, 101790 | 1369.78d | 12d | CON | HARIS | CLOSE |  |
| 101860 |  | Install Backing & Cauld Windows Floor 4 |  | 12d | 2026-11-09 | 2026-11-25 | 101830, 101820 | 1357.78d | 0d | CON | HARIS | CLOSE |  |
| 101840 |  | Stucco Bands |  | 12d | 2026-11-25 | 2026-12-11 | 101790, 101860 | 1357.78d | 0d | CON | HARIS | CLOSE |  |
| 101870 |  | Stucco Grey |  | 24d | 2026-12-11 | 2027-01-14 | 101840 | 1357.78d | 0d | CON | HARIS | CLOSE |  |
| 101940 |  | Stucco Finish Coat |  | 24d | 2027-01-14 | 2027-02-17 | 101870 | 1357.78d | 0d | CON | HARIS | CLOSE |  |
| 102010 |  | Caulk |  | 12.12d | 2027-02-17 | 2027-03-05 | 101940 | 1357.78d | 0d | CON | HARIS | CLOSE |  |
| 102040 |  | Stucco Band Trim |  | 24.12d | 2027-03-05 | 2027-04-08 | 102010 | 1357.78d | 0d | CON | HARIS | CLOSE |  |
| 102100 |  | Paint Exterior |  | 48.12d | 2027-04-08 | 2027-06-15 | 102040 | 1357.78d | 0d | CON | MILLS | CLOSE |  |
| 102110 |  | Install Railings |  | 36.12d | 2027-06-15 | 2027-08-04 | 102100 | 1357.78d | 0d | CON | MILLS | CLOSE |  |
| 102180 |  | Demobilize Scaffolding |  | 12.12d | 2027-06-15 | 2027-07-01 | 102100 | 1369.78d | 0d | CON | MILLS | CLOSE |  |
| 102200 |  | Shell Complete | milestone | 0d | 2027-08-04 | 2027-08-04 | 102180, 102110 | 1357.78d | 0d | CON | MILLS | CLOSE | Key MS |

| ID | WBS | Activity | Type | Duration | Start | Finish | Predecessors | Total float | Free float | Constraint | Department | Responsibility | Phase | Key Milestones |
| --- | --- | --- | --- | --- | --- | --- | --- | --- | --- | --- | --- | --- | --- | --- |
|  | 4 | **Interior Finishes** |  |  | 2026-10-08 | 2033-02-04 |  |  |  |  |  |  |  |  |
| 101900 |  | Unit Finishes Building North - Floor 1 |  | 201.6d | 2026-10-08 | 2027-07-19 | 101760, 101770 | 0d |  |  | CON | HARIS | FINSH |  |
| 101920 |  | Unit Finishes Building South - Floor 1 |  | 201.6d | 2027-07-19 | 2028-04-25 | 101900 | 0d |  |  | CON | HARIS | FINSH |  |
| 101930 |  | Building 1 Elevators Complete |  | 69.6d | 2027-07-19 | 2027-10-22 | 101910, 101900, 101670 | 525.6d |  |  | CON | HARIS | FINSH |  |
| 101960 |  | Unit Finishes Building North - Floor 2 |  | 196.8d | 2028-04-25 | 2029-01-25 | 101920 | 0d |  |  | CON | HARIS | FINSH |  |
| 102000 |  | Unit Finishes Building South - Floor 2 |  | 196.8d | 2029-01-25 | 2029-10-29 | 101960 | 0d |  |  | CON | HARIS | FINSH |  |
| 102030 |  | Unit Finishes Building North - Floor 3 |  | 196.8d | 2029-10-29 | 2030-07-31 | 102000, 101930 | 0d |  |  | CON | HARIS | FINSH |  |
| 102050 |  | Unit Finishes Building South - Floor 3 |  | 196.8d | 2030-07-31 | 2031-05-02 | 102030 | 0d |  |  | CON | HARIS | FINSH |  |
| 102080 |  | Unit Finishes Building North - Floor 4 |  | 194.4d | 2031-05-02 | 2032-01-29 | 102050 | 0d |  |  | CON | MILLS | FINSH |  |
| 102090 |  | Unit Finishes Building South - Floor 4 |  | 194.4d | 2032-01-29 | 2032-10-27 | 102080 | 0d |  |  | CON | MILLS | FINSH |  |
| 102280 |  | Final Inspections and Punchlist |  | 72d | 2032-10-27 | 2033-02-04 | 102030, 102050, 101900, 102080, 102090, 101960, 102000, 101920 | 0d |  |  | CON | MILLS | FINSH |  |
|  | 5 | **Courtyard** |  |  | 2027-07-01 | 2027-11-08 |  |  |  |  |  |  |  |  |
| 102210 |  | Courtyard Walks and Amenities |  | 91.33d | 2027-07-01 | 2027-11-08 | 102180 | 1369.78d |  |  | CON | MILLS | DESGN |  |
|  | 5 | **Garage 1** |  |  | 2026-03-20 | 2027-09-30 |  |  |  |  |  |  |  |  |
| 101370 |  | Start Garage | milestone | 0d | 2026-03-20 | 2026-03-20 |  | 1195.08d | 0d | as late as possible | CON | EVANS | STRUC | Key MS |
| 101380 |  | Shop Drawings, Review & Approval |  | 72.12d | 2026-03-20 | 2026-06-30 | 101370 | 1195.08d | 0d | as late as possible | ENG | EVANS | DESGN |  |
| 101710 |  | Fab & Delivery |  | 72.12d | 2026-06-30 | 2026-10-08 | 101380 | 1195.08d | 0d | as late as possible | ENG | HARIS | PROCR |  |
| 101980 |  | Erect Precast Structure |  | 96d | 2026-10-08 | 2027-02-19 | 101710, 101910 | 1195.08d | 0d |  | CON | HARIS | STRUC |  |
| 102160 |  | Fire Protection and Lighting |  | 72.12d | 2027-02-19 | 2027-06-01 | 101980 | 1396.55d | 0d |  | ENG | MILLS | DESGN |  |
| 102190 |  | Finishes, Barrier Cables & Striping |  | 72.12d | 2027-06-01 | 2027-09-09 | 102160 | 1396.55d | 0d |  | CON | MILLS | DESGN |  |
| 102250 |  | Punchlist Garage |  | 14.4d | 2027-09-10 | 2027-09-30 | 102190 | 1396.55d | 0d |  | CON | MILLS | FINSH |  |
| 102260 |  | Complete Garage 1 | milestone | 0d | 2027-09-30 | 2027-09-30 | 102270 | 1396.55d |  |  | CON | MILLS | FINSH | Key MS |
| 102270 |  | Complete Garage | milestone | 0d | 2027-09-30 | 2027-09-30 | 102190, 102250 | 1396.55d | 0d |  | CON | MILLS | FINSH | Key MS |
|  | 6 | **Garage 2** |  |  | 2025-02-26 | 2026-11-10 |  |  |  |  |  |  |  |  |
| 101020 |  | Design Building Addition | milestone | 0d | 2025-02-26 | 2025-02-26 |  | 1628.45d | 0d | as late as possible | CON | MILLS | ROUGH | Key MS |
| 101030 |  | Shop Drawings, Review and Approval |  | 72.12d | 2025-02-26 | 2025-06-06 | 101020 | 1628.45d | 0d | as late as possible | ENG | FOLEY | DESGN |  |
| 101140 |  | Fab & Delivery |  | 72d | 2025-06-06 | 2025-09-16 | 101030 | 1628.45d | 0d | as late as possible | ENG | FOLEY | PROCR |  |
| 101240 |  | Erect Precast Structure |  | 96.12d | 2025-09-16 | 2026-01-28 | 101140 | 1628.45d | 0d |  | ENG | FOLEY | STRUC |  |
| 101510 |  | Fire Protection and Lighting |  | 72.12d | 2026-01-28 | 2026-05-08 | 101240 | 1628.45d | 0d |  | ENG | EVANS | DESGN |  |
| 101600 |  | Finishes and Striping |  | 84d | 2026-05-08 | 2026-09-03 | 101510 | 1628.45d | 0d |  | CON | EVANS | FINSH |  |
| 101950 |  | Punch List Garage |  | 48.12d | 2026-09-03 | 2026-11-10 | 101600 | 1628.45d | 0d |  | CON | HARIS | FINSH |  |
| 102060 |  | Complete Garage 2 | milestone | 0d | 2026-11-10 | 2026-11-10 | 102070 | 1628.45d |  |  | CON | HARIS | FINSH | Key MS |
| 102070 |  | Complete Garage | milestone | 0d | 2026-11-10 | 2026-11-10 | 101600, 101950 | 1628.45d | 0d |  | CON | HARIS | FINSH | Key MS |

Notes:
- 101980: Anticipated Problems: jdfpje dkdl;sm / Steps: Masonry; Colar Beam; Roof Trusses; Widows & Doors; Wall Finishes; Roof Membrane & Tiles; Plumbing; Electrical; HVAC; Lockup; FF&E; Tile Flooring

| ID | WBS | Activity | Duration | Start | Finish | Predecessors | Total float | Free float | Department | Responsibility | Phase |
| --- | --- | --- | --- | --- | --- | --- | --- | --- | --- | --- | --- |
|  | 7 | **Roads, Utilities & Pavers** |  | 2025-02-26 | 2027-11-24 |  |  |  |  |  |  |
| 101000 |  | Curbing | 72.12d | 2025-02-26 | 2025-06-06 |  | 1818.3d | 0d | CON | FOLEY | FOUND |
| 101040 |  | Electric to Building 4 Power Vault | 72.12d | 2025-02-26 | 2025-06-06 |  | 2000.83d |  | ENG | EVANS | DESGN |
| 101050 |  | Electric to Building 3 Power Vault | 24.12d | 2025-02-26 | 2025-04-01 |  | 2048.82d |  | ENG | FOLEY | DESGN |
| 101080 |  | Storm Drainage Site Work | 72.12d | 2025-02-26 | 2025-06-06 | 101060 | 0d |  | CON | EVANS | ROUGH |
| 101090 |  | Site Electrical Work & Temp Power | 12.12d | 2025-06-06 | 2025-06-24 | 101080 | 0d |  | ENG | NOLAN | ROUGH |
| 101100 |  | Walkways | 67.2d | 2025-06-06 | 2025-09-09 | 101000 | 1818.3d | 0d | ENG | NOLAN | ROUGH |
| 101160 |  | Roadway Pavers | 67.2d | 2025-09-09 | 2025-12-11 | 101100 | 1818.3d | 0d | ENG | NOLAN | DESGN |
| 101230 |  | Finish Paving, Striping and Signs | 48.12d | 2025-12-11 | 2026-02-17 | 101000, 101100, 101160 | 1818.3d |  | ENG | FOLEY | FINSH |
| 101530 |  | Curbs & Paving | 57.73d | 2026-01-28 | 2026-04-17 | 101240 | 1774.97d |  | ENG | EVANS | DESGN |
| 101390 |  | Electric to Building 2 Power Vault | 91.33d | 2026-04-14 | 2026-08-19 | 101080, 101310 | 782.52d | 175.45d | ENG | EVANS | DESGN |
| 101670 |  | Electric to Building 1 Power Vault | 69.72d | 2026-07-02 | 2026-10-08 | 101560 | 727.33d | 201.72d | CON | EVANS | ROUGH |
| 102130 |  | Fountain/Water Feature | 115.33d | 2027-02-19 | 2027-08-02 | 101980 | 1439.88d | 1361.17d | ENG | MILLS | DESGN |
| 102140 |  | Entry Feature/Sign Wall | 103.33d | 2027-02-19 | 2027-07-15 | 102020, 101980 | 1451.88d | 1373.17d | ENG | MASON | DESGN |
| 102170 |  | Curbs & Paving | 72.12d | 2027-02-19 | 2027-06-01 | 102020, 101980 | 1195.08d | 81.85d | CON | MILLS | DESGN |
| 102220 |  | Curbs & Paving | 79.33d | 2027-08-04 | 2027-11-24 | 102200 | 1357.78d |  | CON | MILLS | DESGN |
|  | 8 | **Landscape & Irrigation** |  | 2025-09-09 | 2028-10-31 |  |  |  |  |  |  |
| 101520 |  | Site Cleanup | 48.12d | 2025-09-09 | 2025-11-14 | 101000, 101100 | 1885.5d |  | ENG | EVANS | FINSH |
| 102230 |  | Landscape & Irrigation | 288d | 2027-09-23 | 2028-10-31 | 102150, 101980, 102020, 102170 | 1113.22d | 1034.53d | ENG | MILLS | ROUGH |

## Activity codes

| Code | Value | Meaning |
| --- | --- | --- |
| Department | CON | Construction Department |
| Department | ENG | Engineering Department |
| Key Milestones | Key MS | Key Milestones |
| Phase | CLOSE | Close-In Phase |
| Phase | DESGN | Design and Engineering Phase |
| Phase | FINSH | Finishes and Closeout Phase |
| Phase | FOUND | Foundation Construction Phase |
| Phase | PROCR | Procurement Phase |
| Phase | ROUGH | Rough-In Phase |
| Phase | STRUC | Structural Phase |
| Responsibility | EVANS | Tim Evans |
| Responsibility | FOLEY | Meg Foley |
| Responsibility | HARIS | Linda Haris |
| Responsibility | MASON | Andy Mason |
| Responsibility | MILLS | Tom Mills |
| Responsibility | NOLAN | Joe Nolan |

## Issues

| Issue | Status | Raised | Activity | Notes |
| --- | --- | --- | --- | --- |
| Unit Finishes Experiencing Productivity Delays | IS_Open | 2005-01-17 | 101480 |  |
| Forecast Overrun | IS_Open | 2005-01-19 | 101480 | Jeff: / I noticed that the forecast for Autumn Breezes shows a $512,000 cost overrun. I dug into it a little bit and found the problem area is in Building 1 Interior Finishes . I remember you telling me that we were having some problems with that subcontractor's productivity. Is this still the case? We are only 6 months into this project and I don't want this problem to grow. Can you fill me in on what is happening and you and I can work together to resolve it. / Thanks for your help and hard work! / Bruce / V.P. of Construction |
| Finish Date Variance (days) is -6d on WBS: Harbour Pointe.1.2 | IS_Open | 2007-07-01 |  |  |
| Finish Date Variance (days) is -36d on WBS: Harbour Pointe.5 | IS_Open | 2007-07-01 |  |  |
| Finish Date Variance (days) is -21d on WBS: Harbour Pointe.2.3 | IS_Open | 2007-07-01 |  |  |
| Building 2 Subject To Delay | IS_Open | 2007-04-09 |  | This is an issue connected with productivity delays on Unit / Finishes in Building 1. Building 2 first floor finishes are to be completed by / the same subcontractor that is experience delays now. Recommend official / correspondence to Finshes Subcontractor and consider augmenting crews in / Building 2 to pick-up delay. |
| Finish Date Variance (days) is -21d on WBS: Harbour Pointe.2.4 | IS_Open | 2007-07-01 |  |  |
| Finish Date Variance (days) is -21d on WBS: Harbour Pointe.2.5 | IS_Open | 2007-07-01 |  |  |
| Finish Date Variance (days) is -26d on WBS: Harbour Pointe.8 | IS_Open | 2007-07-01 |  |  |
